# OBRAS ARQUITECTURA Y PAISAJISMO

How a schedule from Primavera P6 changed from version to version. A marks actual dates.

## Version 1 (data date 2024-04-16, saved 2024-04-16, file CEO_AP_LA Rev2.xer)

| ID | WBS | Task | Duration | Start | Finish | Predecessors | Total float |
| --- | --- | --- | --- | --- | --- | --- | --- |
|  | 01 | **OBRAS PRELIMINARES** |  | 2024-04-16 | 2024-04-25 |  |  |
| A1000 |  | INSTALACIONES PROVISIONALES PARA LA OBRA | 9d | 2024-04-16 | 2024-04-25 |  | 0d |
|  | 02 | **ARQUITECTURA Y PAISAJISMO** |  | 2024-04-16 | 2024-11-13 |  |  |
|  | 01 | **INTERVENCIÓN PAISAJISMO - HUMEDAL VILLA MARIA MARGEN DERECHO** |  | 2024-04-16 | 2024-11-13 |  |  |
|  | 01 | **OBRAS PRELIMINARES** |  | 2024-04-16 | 2024-10-24 |  |  |
| A1010 |  | MOVILIZACIÓN Y DEMOVILIZACIÓN DE EQUIPOS Y HERRAMIENTAS (ARQUITECTURA Y PAISAJISMO) | 15d | 2024-04-16 | 2024-05-02 | A1000 SS | 17d |
| A1030 |  | ELIMINACION DE RESIDUOS SOLIDOS GENERALES MUNICIPALES | 66d | 2024-04-26 | 2024-07-11 | A1000 | 0d |
| A1020 |  | TRAZO Y REPLANTEO PRELIMINAR | 150d | 2024-05-03 | 2024-10-24 | A1000, A1010 | 17d |
|  | 02 | **MOVIMIENTO DE TIERRAS** |  | 2024-06-26 | 2024-10-29 |  |  |
| A1040 |  | CORTE PARA CIMENTACIÓN DE DIQUE NATURALIZADO h=30cm | 15d | 2024-06-26 | 2024-07-12 | A1030 SS+52d, A1020 SS+1d | 0d |
| A1050 |  | PERFILADO Y COMPACTACION EN ZONA DE CORTE | 12d | 2024-07-03 | 2024-07-16 | A1040 SS+6d | 0d |
| A1060 |  | CONFORMACIÓN DE CUERPO DE DIQUE NATURALZADO CON RELLENO COMPACTADO | 37d | 2024-07-17 | 2024-08-28 | A1050, A1030 | 0d |
| A1070 |  | EXCAVACIÓN MANUAL PARA INSTALACIÓN DE BORDILLOS Y CIMENTACIONES | 38d | 2024-08-29 | 2024-10-11 | A1060 | 4d |
| A1080 |  | EXCAVACIÓN PARA MEJORAMIENTO DE SUELO CON TIERRA VEGETAL | 2d | 2024-08-29 | 2024-08-30 | A1060 | 49d |
| A1090 |  | ELIMINACION DE MATERIAL EXCEDENTE (DME´S) | 15d | 2024-10-12 | 2024-10-29 | A1040, A1070, A1080 | 13d |
|  | 03 | **PAVIMENTOS, RECUBRIMIENTOS Y BORDILLOS** |  | 2024-10-03 | 2024-11-12 |  |  |
| A1100 |  | PISO TIERRA APISONADA (h=0.35cm) | 30d | 2024-10-03 | 2024-11-06 | A1190 | 0d |
| A1110 |  | RECUBRIMIENTO DE PIEDRA DEL LUGAR e=0.05cm | 10d | 2024-10-21 | 2024-10-31 | A1100 SS+15d, A1070 | 11d |
| A1120 |  | BORDILLOS DE PIEDRA DEL LUGAR | 20d | 2024-10-21 | 2024-11-12 | A1100 SS+15d, A1070 | 1d |
|  | 04 | **MOBILIARIOS, BARANDAS Y ESCALERAS** |  | 2024-10-17 | 2024-11-13 |  |  |
| A1170 |  | BOLARDOS DE PIEDRA | 24d | 2024-10-17 | 2024-11-13 | A1070, A1100 SS+12d | 0d |
| A1130 |  | TACHOS DE BASURA, INCLUYE CIMENTACIÓN | 20d | 2024-10-21 | 2024-11-12 | A1070, A1100 SS+15d | 1d |
| A1140 |  | BANCAS DE CONCRETO, INCLUYE CIMENTACIÓN | 15d | 2024-10-21 | 2024-11-06 | A1070, A1100 SS+15d | 6d |
| A1150 |  | POSTES DE ILUMINACION, INCLUYE LUMINARIA Y CIMENTACION | 20d | 2024-10-21 | 2024-11-12 | A1070, A1100 SS+15d | 1d |
| A1160 |  | SEÑALETICA INFORMATIVA | 10d | 2024-10-21 | 2024-10-31 | A1070, A1100 SS+15d | 11d |
| A1180 |  | TRANQUERA | 15d | 2024-10-21 | 2024-11-06 | A1070, A1100 SS+15d | 6d |
|  | 05 | **OBRAS PRELIMINARES PAISAJISMO)** |  | 2024-08-29 | 2024-10-02 |  |  |
| A1190 |  | MEJORAMIENTO DE SUELO CON TIERRA DE CHACRA (incluye despedregado y rastrillado) | 30d | 2024-08-29 | 2024-10-02 | A1060 | 0d |
|  | 02 | **INTERVENCIÓN PAISAJISMO - HUMEDAL VILLA MARIA MARGEN IZQUIERDO** |  | 2024-04-16 | 2024-11-13 |  |  |
|  | 01 | **OBRAS PRELIMINARES** |  | 2024-04-16 | 2024-06-20 |  |  |
| A1200 |  | MOVILIZACIÓN Y DEMOVILIZACIÓN DE EQUIPOS Y HERRAMIENTAS (ARQUITECTURA Y PAISAJISMO) | 15d | 2024-04-16 | 2024-05-02 | A1010 SS | 166d |
| A1220 |  | ELIMINACION DE RESIDUOS SOLIDOS GENERALES MUNICIPALES | 48d | 2024-04-26 | 2024-06-20 | A1000 | 0d |
| A1210 |  | TRAZO Y REPLANTEO PRELIMINAR | 1d | 2024-05-03 | 2024-05-03 | A1000, A1200 | 166d |
|  | 02 | **MOVIMIENTO DE TIERRAS** |  | 2024-06-04 | 2024-10-18 |  |  |
| A1230 |  | CORTE PARA CIMENTACIÓN DE DIQUE NATURALIZADO h=30cm | 35d | 2024-06-04 | 2024-07-13 | A1220 SS+33d | 0d |
| A1240 |  | PERFILADO Y COMPACTACION EN ZONA DE CORTE | 14d | 2024-07-09 | 2024-07-24 | A1230 SS+30d | 0d |
| A1250 |  | CONFORMACIÓN DE DIQUE NATURALIZADO O TERRAZA CON RELLENO COMPACTADO | 5d | 2024-07-25 | 2024-07-30 | A1240, A1220, A1040 | 0d |
| A1260 |  | EXCAVACIÓN MANUAL PARA INSTALACIÓN DE BORDILLOS Y CIMENTACIONES | 12d | 2024-07-31 | 2024-08-13 | A1250 | 44d |
| A1270 |  | ELIMINACION DE MATERIAL EXCEDENTE (DME´S) | 35d | 2024-09-09 | 2024-10-18 | A1260, A1230, A1280 | 22d |
|  | 03 | **PAVIMENTOS, RECUBRIMIENTOS Y BORDILLOS** |  | 2024-08-26 | 2024-10-01 |  |  |
| A1280 |  | PISO TIERRA APISONADA (h=0.35cm) | 12d | 2024-08-26 | 2024-09-07 | A1370 | 0d |
| A1290 |  | RECUBRIMIENTO DE PIEDRA DEL LUGAR e=0.05cm | 7d | 2024-09-09 | 2024-09-16 | A1280 | 50d |
| A1300 |  | BORDILLOS DE PIEDRA DEL LUGAR | 20d | 2024-09-09 | 2024-10-01 | A1280 | 37d |
|  | 04 | **MOBILIARIOS, BARANDAS Y ESCALERAS** |  | 2024-08-31 | 2024-11-13 |  |  |
| A1310 |  | TACHOS DE BASURA, INCLUYE CIMENTACIÓN | 25d | 2024-08-31 | 2024-09-28 | A1280 SS+5d | 39d |
| A1320 |  | BANCAS DE CONCRETO, INCLUYE CIMENTACIÓN | 15d | 2024-08-31 | 2024-09-17 | A1280 SS+5d | 49d |
| A1330 |  | POSTES DE ILUMINACION, INCLUYE LUMINARIA Y CIMENTACION | 25d | 2024-08-31 | 2024-09-28 | A1280 SS+5d | 39d |
| A1340 |  | SEÑALETICA INFORMATIVA | 10d | 2024-08-31 | 2024-09-11 | A1280 SS+5d | 54d |
| A1350 |  | BOLARDOS DE PIEDRA | 64d | 2024-08-31 | 2024-11-13 | A1280 SS+5d | 0d |
| A1360 |  | TRANQUERA | 15d | 2024-08-31 | 2024-09-17 | A1280 SS+5d | 49d |
|  | 05 | **OBRAS PRELIMINARES PAISAJISMO** |  | 2024-07-31 | 2024-08-24 |  |  |
| A1370 |  | MEJORAMIENTO DE SUELO CON TIERRA DE CHACRA (incluye despedregado y rastrillado) | 22d | 2024-07-31 | 2024-08-24 | A1250 | 0d |

## Version 2 (data date 2024-12-01, saved 2024-11-10, file SP-A1-2.xer)

Last finish 2024-11-13 → 2025-06-23 (+222d).

Added:

| ID | Task | Duration | Start | Finish | Predecessors | Resources |
| --- | --- | --- | --- | --- | --- | --- |
| .0 | **HITOS** |  | 2024-12-01 | 2025-06-23 |  |  |
| H1000 | KOM | 0d | 2024-12-01 | 2024-12-01 |  |  |
| H1100 | INICIO DE PLAZO CONTRACTUAL - ACCESO AL SITIO | 0d | 2024-12-17 | 2024-12-17 | A1040 |  |
| H1200 | FIN DE PLAZO CONTRACTUAL - CULMINACION DE OBRAS | 0d | 2025-06-23 | 2025-06-23 | A1400 FF |  |
| 1 | **TRANSPORTE DE MATERIAL** |  | 2024-12-17 | 2025-04-13 |  |  |
| A1020 | TRANSPORTE DE MATERIAL EXCEDENTE PARA DISTANCIAS <1KM | 118d | 2024-12-17 | 2025-04-13 | A1690 SS | CAPATAZ; OPERARIO [669.3 h]; OFICIAL; PEON [334.65 h]; VOLQUETES [669.3 h]; CISTERNA; CAMION GRUA BARANDA 3 TN; CARGADOR FRONTAL; EXCAVADORA SOBRE ORUGAS 180-348 HP [167.32 h]; DUMPER DE DESCARGA FRONTA 2 TN; MOTONIVELADORA 145 -150HP; TRACTOR SOBREORUGAS 300-330HP; TRACTOR SOBREORUGAS 170-220HP; RETROEXCAVADORA; MIXER DE CONCRETO; RODILLO BERMERO; RODILLO LISO VIBR. AUTOPROPULSADO 101-135HP 10-12TN |
| A1030 | TRANSPORTE DE MATERIAL EXCEDENTE PARA DISTANCIAS >1KM | 118d | 2024-12-17 | 2025-04-13 | A1690 SS | CAPATAZ; OPERARIO; OFICIAL; PEON; VOLQUETES [5649.23 h]; CISTERNA; CAMION GRUA BARANDA 3 TN; CARGADOR FRONTAL; EXCAVADORA SOBRE ORUGAS 180-348 HP; DUMPER DE DESCARGA FRONTA 2 TN; MOTONIVELADORA 145 -150HP; TRACTOR SOBREORUGAS 300-330HP; TRACTOR SOBREORUGAS 170-220HP; RETROEXCAVADORA; MIXER DE CONCRETO; RODILLO BERMERO; RODILLO LISO VIBR. AUTOPROPULSADO 101-135HP 10-12TN |
| A1010 | TRANSPORTE DE MATERIAL GRANULAR PARA DISTANCIAS >1KM | 107d | 2024-12-19 | 2025-04-04 | A1710 SS | CAPATAZ; OPERARIO; OFICIAL; PEON; VOLQUETES [7634.86 h]; CISTERNA; CAMION GRUA BARANDA 3 TN; CARGADOR FRONTAL; EXCAVADORA SOBRE ORUGAS 180-348 HP; DUMPER DE DESCARGA FRONTA 2 TN; MOTONIVELADORA 145 -150HP; TRACTOR SOBREORUGAS 300-330HP; TRACTOR SOBREORUGAS 170-220HP; RETROEXCAVADORA; MIXER DE CONCRETO; RODILLO BERMERO; RODILLO LISO VIBR. AUTOPROPULSADO 101-135HP 10-12TN |
| 2 | **INTERVENCIÓN PAISAJISMO - HUMEDAL VILLA MARIA MARGEN DERECHO - ARQUITECTURA Y PAISAJISMO** |  | 2024-12-01 | 2025-06-12 |  |  |
| 6 | **FASE 1 - TRAMOS SIN RESTRICCION PREDIAL** |  | 2024-12-01 | 2025-02-23 |  |  |
| 3 | **PK 0+000 - PK 0+300** |  | 2024-12-17 | 2025-02-19 |  |  |
| 2 | **PK 0+422 - PK 0+920** |  | 2024-12-19 | 2025-02-20 |  |  |
| A1770 | CONFORMACIÓN DE CUERPO DE DIQUE NATURALZADO CON RELLENO COMPACTADO | 10d | 2024-12-26 | 2025-01-04 | A1760, A1710 | CAPATAZ [9.71 h]; OPERARIO [97.06 h]; OFICIAL [97.06 h]; PEON [194.13 h]; VOLQUETES; CISTERNA [97.06 h]; CAMION GRUA BARANDA 3 TN; CARGADOR FRONTAL [24.27 h]; EXCAVADORA SOBRE ORUGAS 180-348 HP; DUMPER DE DESCARGA FRONTA 2 TN; MOTONIVELADORA 145 -150HP [97.06 h]; TRACTOR SOBREORUGAS 300-330HP; TRACTOR SOBREORUGAS 170-220HP; RETROEXCAVADORA; MIXER DE CONCRETO; RODILLO BERMERO; RODILLO LISO VIBR. AUTOPROPULSADO 101-135HP 10-12TN [97.06 h]; RELLENOS [4853.13] |
| A1790 | EXCAVACIÓN PARA MEJORAMIENTO DE SUELO CON TIERRA VEGETAL | 1d | 2025-02-20 | 2025-02-20 | A1780, A1730 | CAPATAZ [0.04 h]; OPERARIO [0.44 h]; OFICIAL [0.22 h]; PEON [0.44 h]; VOLQUETES; CISTERNA; CAMION GRUA BARANDA 3 TN; CARGADOR FRONTAL; EXCAVADORA SOBRE ORUGAS 180-348 HP [0.44 h]; DUMPER DE DESCARGA FRONTA 2 TN; MOTONIVELADORA 145 -150HP; TRACTOR SOBREORUGAS 300-330HP [0.22 h]; TRACTOR SOBREORUGAS 170-220HP; RETROEXCAVADORA; MIXER DE CONCRETO; RODILLO BERMERO; RODILLO LISO VIBR. AUTOPROPULSADO 101-135HP 10-12TN |
| 4 | **PK 0+970 - PK 1+510** |  | 2024-12-22 | 2025-02-21 |  |  |
| A1630 | CORTE PARA CIMENTACIÓN DE DIQUE NATURALIZADO h=30cm | 4d | 2024-12-22 | 2024-12-25 | A1750 | CAPATAZ [30.08 h]; OPERARIO [30.08 h]; OFICIAL [30.08 h]; PEON [180.48 h]; VOLQUETES; CISTERNA; CAMION GRUA BARANDA 3 TN; CARGADOR FRONTAL; EXCAVADORA SOBRE ORUGAS 180-348 HP [30.08 h]; DUMPER DE DESCARGA FRONTA 2 TN; MOTONIVELADORA 145 -150HP; TRACTOR SOBREORUGAS 300-330HP; TRACTOR SOBREORUGAS 170-220HP; RETROEXCAVADORA; MIXER DE CONCRETO; RODILLO BERMERO; RODILLO LISO VIBR. AUTOPROPULSADO 101-135HP 10-12TN; EXCAVACION [1955.16] |
| A1640 | PERFILADO Y COMPACTACION EN ZONA DE CORTE | 4d | 2024-12-26 | 2024-12-29 | A1630, A1760 | CAPATAZ [3.31 h]; OPERARIO; OFICIAL [33.07 h]; PEON [33.07 h]; VOLQUETES; CISTERNA [33.07 h]; CAMION GRUA BARANDA 3 TN; CARGADOR FRONTAL; EXCAVADORA SOBRE ORUGAS 180-348 HP [33.07 h]; DUMPER DE DESCARGA FRONTA 2 TN; MOTONIVELADORA 145 -150HP [33.07 h]; TRACTOR SOBREORUGAS 300-330HP; TRACTOR SOBREORUGAS 170-220HP [16.54 h]; RETROEXCAVADORA; MIXER DE CONCRETO; RODILLO BERMERO; RODILLO LISO VIBR. AUTOPROPULSADO 101-135HP 10-12TN [33.07 h]; PERFILADO [9922.03] |
| A1650 | CONFORMACIÓN DE CUERPO DE DIQUE NATURALZADO CON RELLENO COMPACTADO | 11d | 2025-01-05 | 2025-01-15 | A1640, A1770 | CAPATAZ [10.52 h]; OPERARIO [105.25 h]; OFICIAL [105.25 h]; PEON [210.5 h]; VOLQUETES; CISTERNA [105.25 h]; CAMION GRUA BARANDA 3 TN; CARGADOR FRONTAL [26.31 h]; EXCAVADORA SOBRE ORUGAS 180-348 HP; DUMPER DE DESCARGA FRONTA 2 TN; MOTONIVELADORA 145 -150HP [105.25 h]; TRACTOR SOBREORUGAS 300-330HP; TRACTOR SOBREORUGAS 170-220HP; RETROEXCAVADORA; MIXER DE CONCRETO; RODILLO BERMERO; RODILLO LISO VIBR. AUTOPROPULSADO 101-135HP 10-12TN [105.25 h]; RELLENOS [5262.42] |
| A1660 | EXCAVACIÓN MANUAL PARA INSTALACIÓN DE BORDILLOS Y CIMENTACIONES | 13d | 2025-01-20 | 2025-02-01 | A1650, A1780 | CAPATAZ; OPERARIO; OFICIAL [122.96 h]; PEON [491.85 h]; VOLQUETES; CISTERNA; CAMION GRUA BARANDA 3 TN; CARGADOR FRONTAL; EXCAVADORA SOBRE ORUGAS 180-348 HP; DUMPER DE DESCARGA FRONTA 2 TN; MOTONIVELADORA 145 -150HP; TRACTOR SOBREORUGAS 300-330HP; TRACTOR SOBREORUGAS 170-220HP; RETROEXCAVADORA; MIXER DE CONCRETO; RODILLO BERMERO; RODILLO LISO VIBR. AUTOPROPULSADO 101-135HP 10-12TN |
| A1670 | EXCAVACIÓN PARA MEJORAMIENTO DE SUELO CON TIERRA VEGETAL | 1d | 2025-02-21 | 2025-02-21 | A1660, A1790 | CAPATAZ [0.05 h]; OPERARIO [0.48 h]; OFICIAL [0.24 h]; PEON [0.48 h]; VOLQUETES; CISTERNA; CAMION GRUA BARANDA 3 TN; CARGADOR FRONTAL; EXCAVADORA SOBRE ORUGAS 180-348 HP [0.48 h]; DUMPER DE DESCARGA FRONTA 2 TN; MOTONIVELADORA 145 -150HP; TRACTOR SOBREORUGAS 300-330HP [0.24 h]; TRACTOR SOBREORUGAS 170-220HP; RETROEXCAVADORA; MIXER DE CONCRETO; RODILLO BERMERO; RODILLO LISO VIBR. AUTOPROPULSADO 101-135HP 10-12TN |
| 5 | **PK 2+325 - PK 2+710** |  | 2024-12-26 | 2025-02-22 |  |  |
| A1570 | CORTE PARA CIMENTACIÓN DE DIQUE NATURALIZADO h=30cm | 2d | 2024-12-26 | 2024-12-27 | A1630 | CAPATAZ [21.45 h]; OPERARIO [21.45 h]; OFICIAL [21.45 h]; PEON [128.67 h]; VOLQUETES; CISTERNA; CAMION GRUA BARANDA 3 TN; CARGADOR FRONTAL; EXCAVADORA SOBRE ORUGAS 180-348 HP [21.45 h]; DUMPER DE DESCARGA FRONTA 2 TN; MOTONIVELADORA 145 -150HP; TRACTOR SOBREORUGAS 300-330HP; TRACTOR SOBREORUGAS 170-220HP; RETROEXCAVADORA; MIXER DE CONCRETO; RODILLO BERMERO; RODILLO LISO VIBR. AUTOPROPULSADO 101-135HP 10-12TN; EXCAVACION [1393.96] |
| A1580 | PERFILADO Y COMPACTACION EN ZONA DE CORTE | 2d | 2024-12-30 | 2024-12-31 | A1570, A1640 | CAPATAZ [2.36 h]; OPERARIO; OFICIAL [23.58 h]; PEON [23.58 h]; VOLQUETES; CISTERNA [23.58 h]; CAMION GRUA BARANDA 3 TN; CARGADOR FRONTAL; EXCAVADORA SOBRE ORUGAS 180-348 HP [23.58 h]; DUMPER DE DESCARGA FRONTA 2 TN; MOTONIVELADORA 145 -150HP [23.58 h]; TRACTOR SOBREORUGAS 300-330HP; TRACTOR SOBREORUGAS 170-220HP [11.79 h]; RETROEXCAVADORA; MIXER DE CONCRETO; RODILLO BERMERO; RODILLO LISO VIBR. AUTOPROPULSADO 101-135HP 10-12TN [23.58 h]; PERFILADO [7074.04] |
| A1590 | CONFORMACIÓN DE CUERPO DE DIQUE NATURALZADO CON RELLENO COMPACTADO | 4d | 2025-01-16 | 2025-01-19 | A1580, A1650 | CAPATAZ [7.5 h]; OPERARIO [75.04 h]; OFICIAL [75.04 h]; PEON [150.08 h]; VOLQUETES; CISTERNA [75.04 h]; CAMION GRUA BARANDA 3 TN; CARGADOR FRONTAL [18.76 h]; EXCAVADORA SOBRE ORUGAS 180-348 HP; DUMPER DE DESCARGA FRONTA 2 TN; MOTONIVELADORA 145 -150HP [75.04 h]; TRACTOR SOBREORUGAS 300-330HP; TRACTOR SOBREORUGAS 170-220HP; RETROEXCAVADORA; MIXER DE CONCRETO; RODILLO BERMERO; RODILLO LISO VIBR. AUTOPROPULSADO 101-135HP 10-12TN [75.04 h]; RELLENOS [3751.91] |
| A1600 | EXCAVACIÓN MANUAL PARA INSTALACIÓN DE BORDILLOS Y CIMENTACIONES | 5d | 2025-02-02 | 2025-02-06 | A1590, A1660 | CAPATAZ; OPERARIO; OFICIAL [87.67 h]; PEON [350.67 h]; VOLQUETES; CISTERNA; CAMION GRUA BARANDA 3 TN; CARGADOR FRONTAL; EXCAVADORA SOBRE ORUGAS 180-348 HP; DUMPER DE DESCARGA FRONTA 2 TN; MOTONIVELADORA 145 -150HP; TRACTOR SOBREORUGAS 300-330HP; TRACTOR SOBREORUGAS 170-220HP; RETROEXCAVADORA; MIXER DE CONCRETO; RODILLO BERMERO; RODILLO LISO VIBR. AUTOPROPULSADO 101-135HP 10-12TN |
| A1610 | EXCAVACIÓN PARA MEJORAMIENTO DE SUELO CON TIERRA VEGETAL | 1d | 2025-02-22 | 2025-02-22 | A1600, A1670 | CAPATAZ [0.03 h]; OPERARIO [0.34 h]; OFICIAL [0.17 h]; PEON [0.34 h]; VOLQUETES; CISTERNA; CAMION GRUA BARANDA 3 TN; CARGADOR FRONTAL; EXCAVADORA SOBRE ORUGAS 180-348 HP [0.34 h]; DUMPER DE DESCARGA FRONTA 2 TN; MOTONIVELADORA 145 -150HP; TRACTOR SOBREORUGAS 300-330HP [0.17 h]; TRACTOR SOBREORUGAS 170-220HP; RETROEXCAVADORA; MIXER DE CONCRETO; RODILLO BERMERO; RODILLO LISO VIBR. AUTOPROPULSADO 101-135HP 10-12TN |
| 7 | **PK 2+922 A PK 3+176** |  | 2024-12-28 | 2025-02-23 |  |  |
| A1070 | CORTE PARA CIMENTACIÓN DE DIQUE NATURALIZADO h=30cm | 1d | 2024-12-28 | 2024-12-28 | A1570 | CAPATAZ [14.15 h]; OPERARIO [14.15 h]; OFICIAL [14.15 h]; PEON [84.89 h]; VOLQUETES; CISTERNA; CAMION GRUA BARANDA 3 TN; CARGADOR FRONTAL; EXCAVADORA SOBRE ORUGAS 180-348 HP [14.15 h]; DUMPER DE DESCARGA FRONTA 2 TN; MOTONIVELADORA 145 -150HP; TRACTOR SOBREORUGAS 300-330HP; TRACTOR SOBREORUGAS 170-220HP; RETROEXCAVADORA; MIXER DE CONCRETO; RODILLO BERMERO; RODILLO LISO VIBR. AUTOPROPULSADO 101-135HP 10-12TN; EXCAVACION [919.65] |
| A1080 | PERFILADO Y COMPACTACION EN ZONA DE CORTE | 1d | 2025-01-01 | 2025-01-01 | A1070, A1580 | CAPATAZ [1.56 h]; OPERARIO; OFICIAL [15.56 h]; PEON [15.56 h]; VOLQUETES; CISTERNA [15.56 h]; CAMION GRUA BARANDA 3 TN; CARGADOR FRONTAL; EXCAVADORA SOBRE ORUGAS 180-348 HP [15.56 h]; DUMPER DE DESCARGA FRONTA 2 TN; MOTONIVELADORA 145 -150HP [15.56 h]; TRACTOR SOBREORUGAS 300-330HP; TRACTOR SOBREORUGAS 170-220HP [7.78 h]; RETROEXCAVADORA; MIXER DE CONCRETO; RODILLO BERMERO; RODILLO LISO VIBR. AUTOPROPULSADO 101-135HP 10-12TN [15.56 h]; PERFILADO [4667.03] |
| A1090 | CONFORMACIÓN DE CUERPO DE DIQUE NATURALZADO CON RELLENO COMPACTADO | 3d | 2025-01-20 | 2025-01-22 | A1080, A1590 | CAPATAZ [4.95 h]; OPERARIO [49.51 h]; OFICIAL [49.51 h]; PEON [99.01 h]; VOLQUETES; CISTERNA [49.51 h]; CAMION GRUA BARANDA 3 TN; CARGADOR FRONTAL [12.38 h]; EXCAVADORA SOBRE ORUGAS 180-348 HP; DUMPER DE DESCARGA FRONTA 2 TN; MOTONIVELADORA 145 -150HP [49.51 h]; TRACTOR SOBREORUGAS 300-330HP; TRACTOR SOBREORUGAS 170-220HP; RETROEXCAVADORA; MIXER DE CONCRETO; RODILLO BERMERO; RODILLO LISO VIBR. AUTOPROPULSADO 101-135HP 10-12TN [49.51 h]; RELLENOS [2475.29] |
| A1100 | EXCAVACIÓN MANUAL PARA INSTALACIÓN DE BORDILLOS Y CIMENTACIONES | 3d | 2025-02-07 | 2025-02-09 | A1090, A1600 | CAPATAZ; OPERARIO; OFICIAL [57.84 h]; PEON [231.35 h]; VOLQUETES; CISTERNA; CAMION GRUA BARANDA 3 TN; CARGADOR FRONTAL; EXCAVADORA SOBRE ORUGAS 180-348 HP; DUMPER DE DESCARGA FRONTA 2 TN; MOTONIVELADORA 145 -150HP; TRACTOR SOBREORUGAS 300-330HP; TRACTOR SOBREORUGAS 170-220HP; RETROEXCAVADORA; MIXER DE CONCRETO; RODILLO BERMERO; RODILLO LISO VIBR. AUTOPROPULSADO 101-135HP 10-12TN |
| A1110 | EXCAVACIÓN PARA MEJORAMIENTO DE SUELO CON TIERRA VEGETAL | 1d | 2025-02-23 | 2025-02-23 | A1100, A1610 | CAPATAZ [0.02 h]; OPERARIO [0.23 h]; OFICIAL [0.11 h]; PEON [0.23 h]; VOLQUETES; CISTERNA; CAMION GRUA BARANDA 3 TN; CARGADOR FRONTAL; EXCAVADORA SOBRE ORUGAS 180-348 HP [0.23 h]; DUMPER DE DESCARGA FRONTA 2 TN; MOTONIVELADORA 145 -150HP; TRACTOR SOBREORUGAS 300-330HP [0.11 h]; TRACTOR SOBREORUGAS 170-220HP; RETROEXCAVADORA; MIXER DE CONCRETO; RODILLO BERMERO; RODILLO LISO VIBR. AUTOPROPULSADO 101-135HP 10-12TN |
| 2 | **FASE 2 - TRAMOS CON RESTRICCION PREDIAL** |  | 2024-12-01 | 2025-04-03 |  |  |
| A1810 | CORTE PARA CIMENTACIÓN DE DIQUE NATURALIZADO h=30cm | 4d | 2025-02-10 | 2025-02-13 | A1100 | EXCAVACION [4732.22]; CAPATAZ [72.8 h]; OPERARIO [72.8 h]; OFICIAL [72.8 h]; PEON [436.82 h]; VOLQUETES; CISTERNA; CAMION GRUA BARANDA 3 TN; CARGADOR FRONTAL; EXCAVADORA SOBRE ORUGAS 180-348 HP [72.8 h]; DUMPER DE DESCARGA FRONTA 2 TN; MOTONIVELADORA 145 -150HP; TRACTOR SOBREORUGAS 300-330HP; TRACTOR SOBREORUGAS 170-220HP; RETROEXCAVADORA; MIXER DE CONCRETO; RODILLO BERMERO; RODILLO LISO VIBR. AUTOPROPULSADO 101-135HP 10-12TN |
| A1820 | PERFILADO Y COMPACTACION EN ZONA DE CORTE | 5d | 2025-02-14 | 2025-02-18 | A1810 | CAPATAZ [8 h]; OPERARIO; OFICIAL [80.05 h]; PEON [80.05 h]; VOLQUETES; CISTERNA [80.05 h]; CAMION GRUA BARANDA 3 TN; CARGADOR FRONTAL; EXCAVADORA SOBRE ORUGAS 180-348 HP [80.05 h]; DUMPER DE DESCARGA FRONTA 2 TN; MOTONIVELADORA 145 -150HP [80.05 h]; TRACTOR SOBREORUGAS 300-330HP; TRACTOR SOBREORUGAS 170-220HP [40.02 h]; RETROEXCAVADORA; MIXER DE CONCRETO; RODILLO BERMERO; RODILLO LISO VIBR. AUTOPROPULSADO 101-135HP 10-12TN [80.05 h]; PERFILADO [24015] |
| A1830 | CONFORMACIÓN DE CUERPO DE DIQUE NATURALZADO CON RELLENO COMPACTADO | 13d | 2025-02-19 | 2025-03-03 | A1820, A1090 | CAPATAZ [25.47 h]; OPERARIO [254.74 h]; OFICIAL [254.74 h]; PEON [509.48 h]; VOLQUETES; CISTERNA [254.74 h]; CAMION GRUA BARANDA 3 TN; CARGADOR FRONTAL [63.69 h]; EXCAVADORA SOBRE ORUGAS 180-348 HP; DUMPER DE DESCARGA FRONTA 2 TN; MOTONIVELADORA 145 -150HP [254.74 h]; TRACTOR SOBREORUGAS 300-330HP; TRACTOR SOBREORUGAS 170-220HP; RETROEXCAVADORA; MIXER DE CONCRETO; RODILLO BERMERO; RODILLO LISO VIBR. AUTOPROPULSADO 101-135HP 10-12TN [254.74 h]; RELLENOS [12737] |
| A1840 | EXCAVACIÓN MANUAL PARA INSTALACIÓN DE BORDILLOS Y CIMENTACIONES | 30d | 2025-03-04 | 2025-04-02 | A1830, A1110 | CAPATAZ; OPERARIO; OFICIAL [297.62 h]; PEON [1190.47 h]; VOLQUETES; CISTERNA; CAMION GRUA BARANDA 3 TN; CARGADOR FRONTAL; EXCAVADORA SOBRE ORUGAS 180-348 HP; DUMPER DE DESCARGA FRONTA 2 TN; MOTONIVELADORA 145 -150HP; TRACTOR SOBREORUGAS 300-330HP; TRACTOR SOBREORUGAS 170-220HP; RETROEXCAVADORA; MIXER DE CONCRETO; RODILLO BERMERO; RODILLO LISO VIBR. AUTOPROPULSADO 101-135HP 10-12TN |
| A1850 | EXCAVACIÓN PARA MEJORAMIENTO DE SUELO CON TIERRA VEGETAL | 1d | 2025-04-03 | 2025-04-03 | A1840 | CAPATAZ [0.12 h]; OPERARIO [1.16 h]; OFICIAL [0.58 h]; PEON [1.16 h]; VOLQUETES; CISTERNA; CAMION GRUA BARANDA 3 TN; CARGADOR FRONTAL; EXCAVADORA SOBRE ORUGAS 180-348 HP [1.16 h]; DUMPER DE DESCARGA FRONTA 2 TN; MOTONIVELADORA 145 -150HP; TRACTOR SOBREORUGAS 300-330HP [0.58 h]; TRACTOR SOBREORUGAS 170-220HP; RETROEXCAVADORA; MIXER DE CONCRETO; RODILLO BERMERO; RODILLO LISO VIBR. AUTOPROPULSADO 101-135HP 10-12TN |
| 6 | **FASE 1 - TRAMOS SIN RESTRICCION PREDIAL** |  | 2024-12-01 | 2025-04-01 |  |  |
| 2 | **MOVIMIENTO DE TIERRAS** |  | 2024-12-01 | 2025-04-01 |  |  |
| 1 | **PK 0+000 - PK 0+100** |  | 2024-12-01 | 2025-03-03 |  |  |
| A1300 | ELIMINACION DE MATERIAL EXCEDENTE (DME´S) | 0d | 2024-12-01 | 2024-12-01 |  | CAPATAZ; OPERARIO; OFICIAL; PEON; VOLQUETES; CISTERNA; CAMION GRUA BARANDA 3 TN; CARGADOR FRONTAL; EXCAVADORA SOBRE ORUGAS 180-348 HP; DUMPER DE DESCARGA FRONTA 2 TN; MOTONIVELADORA 145 -150HP; TRACTOR SOBREORUGAS 300-330HP; TRACTOR SOBREORUGAS 170-220HP; RETROEXCAVADORA; MIXER DE CONCRETO; RODILLO BERMERO; RODILLO LISO VIBR. AUTOPROPULSADO 101-135HP 10-12TN |
| A1260 | CORTE PARA CIMENTACIÓN DE DIQUE NATURALIZADO h=30cm | 3d | 2025-02-24 | 2025-02-26 | A1240, A1110 | CAPATAZ [47.57 h]; OPERARIO [47.57 h]; OFICIAL [47.57 h]; PEON [285.41 h]; VOLQUETES; CISTERNA; CAMION GRUA BARANDA 3 TN; CARGADOR FRONTAL; EXCAVADORA SOBRE ORUGAS 180-348 HP [47.57 h]; DUMPER DE DESCARGA FRONTA 2 TN; MOTONIVELADORA 145 -150HP; TRACTOR SOBREORUGAS 300-330HP; TRACTOR SOBREORUGAS 170-220HP; RETROEXCAVADORA; MIXER DE CONCRETO; RODILLO BERMERO; RODILLO LISO VIBR. AUTOPROPULSADO 101-135HP 10-12TN; EXCAVACION [3091.93] |
| A1270 | PERFILADO Y COMPACTACION EN ZONA DE CORTE | 1d | 2025-02-27 | 2025-02-27 | A1260 | CAPATAZ [1.97 h]; OPERARIO; OFICIAL [19.66 h]; PEON [19.66 h]; VOLQUETES; CISTERNA [19.66 h]; CAMION GRUA BARANDA 3 TN; CARGADOR FRONTAL; EXCAVADORA SOBRE ORUGAS 180-348 HP [19.66 h]; DUMPER DE DESCARGA FRONTA 2 TN; MOTONIVELADORA 145 -150HP [19.66 h]; TRACTOR SOBREORUGAS 300-330HP; TRACTOR SOBREORUGAS 170-220HP [9.83 h]; RETROEXCAVADORA; MIXER DE CONCRETO; RODILLO BERMERO; RODILLO LISO VIBR. AUTOPROPULSADO 101-135HP 10-12TN [19.66 h]; PERFILADO [5898.62] |
| A1290 | EXCAVACIÓN MANUAL PARA INSTALACIÓN DE BORDILLOS Y CIMENTACIONES | 3d | 2025-03-01 | 2025-03-03 | A1280 | CAPATAZ; OPERARIO; OFICIAL [20.41 h]; PEON [81.66 h]; VOLQUETES; CISTERNA; CAMION GRUA BARANDA 3 TN; CARGADOR FRONTAL; EXCAVADORA SOBRE ORUGAS 180-348 HP; DUMPER DE DESCARGA FRONTA 2 TN; MOTONIVELADORA 145 -150HP; TRACTOR SOBREORUGAS 300-330HP; TRACTOR SOBREORUGAS 170-220HP; RETROEXCAVADORA; MIXER DE CONCRETO; RODILLO BERMERO; RODILLO LISO VIBR. AUTOPROPULSADO 101-135HP 10-12TN |
| 2 | **PK 0+300 - PK 0+821** |  | 2024-12-01 | 2025-04-01 |  |  |
| A1960 | ELIMINACION DE MATERIAL EXCEDENTE (DME´S) | 0d | 2024-12-01 | 2024-12-01 |  | CAPATAZ; OPERARIO; OFICIAL; PEON; VOLQUETES; CISTERNA; CAMION GRUA BARANDA 3 TN; CARGADOR FRONTAL; EXCAVADORA SOBRE ORUGAS 180-348 HP; DUMPER DE DESCARGA FRONTA 2 TN; MOTONIVELADORA 145 -150HP; TRACTOR SOBREORUGAS 300-330HP; TRACTOR SOBREORUGAS 170-220HP; RETROEXCAVADORA; MIXER DE CONCRETO; RODILLO BERMERO; RODILLO LISO VIBR. AUTOPROPULSADO 101-135HP 10-12TN |
| A1920 | CORTE PARA CIMENTACIÓN DE DIQUE NATURALIZADO h=30cm | 13d | 2025-02-28 | 2025-03-12 | A1270 | CAPATAZ [247.83 h]; OPERARIO [247.83 h]; OFICIAL [247.83 h]; PEON [1486.98 h]; VOLQUETES; CISTERNA; CAMION GRUA BARANDA 3 TN; CARGADOR FRONTAL; EXCAVADORA SOBRE ORUGAS 180-348 HP [247.83 h]; DUMPER DE DESCARGA FRONTA 2 TN; MOTONIVELADORA 145 -150HP; TRACTOR SOBREORUGAS 300-330HP; TRACTOR SOBREORUGAS 170-220HP; RETROEXCAVADORA; MIXER DE CONCRETO; RODILLO BERMERO; RODILLO LISO VIBR. AUTOPROPULSADO 101-135HP 10-12TN; EXCAVACION [16108.9] |
| A1930 | PERFILADO Y COMPACTACION EN ZONA DE CORTE | 6d | 2025-03-13 | 2025-03-18 | A1920 | CAPATAZ [10.24 h]; OPERARIO; OFICIAL [102.44 h]; PEON [102.44 h]; VOLQUETES; CISTERNA [102.44 h]; CAMION GRUA BARANDA 3 TN; CARGADOR FRONTAL; EXCAVADORA SOBRE ORUGAS 180-348 HP [102.44 h]; DUMPER DE DESCARGA FRONTA 2 TN; MOTONIVELADORA 145 -150HP [102.44 h]; TRACTOR SOBREORUGAS 300-330HP; TRACTOR SOBREORUGAS 170-220HP [51.22 h]; RETROEXCAVADORA; MIXER DE CONCRETO; RODILLO BERMERO; RODILLO LISO VIBR. AUTOPROPULSADO 101-135HP 10-12TN [102.44 h]; PERFILADO [30731.8] |
| A1940 | CONFORMACIÓN DE DIQUE NATURALIZADO O TERRAZA CON RELLENO COMPACTADO | 3d | 2025-03-19 | 2025-03-21 | A1930 | CAPATAZ [5.57 h]; OPERARIO [55.75 h]; OFICIAL [55.75 h]; PEON [111.49 h]; VOLQUETES; CISTERNA [55.75 h]; CAMION GRUA BARANDA 3 TN; CARGADOR FRONTAL [13.94 h]; EXCAVADORA SOBRE ORUGAS 180-348 HP; DUMPER DE DESCARGA FRONTA 2 TN; MOTONIVELADORA 145 -150HP [55.75 h]; TRACTOR SOBREORUGAS 300-330HP; TRACTOR SOBREORUGAS 170-220HP; RETROEXCAVADORA; MIXER DE CONCRETO; RODILLO BERMERO; RODILLO LISO VIBR. AUTOPROPULSADO 101-135HP 10-12TN [55.75 h]; RELLENOS [2787.27] |
| A1950 | EXCAVACIÓN MANUAL PARA INSTALACIÓN DE BORDILLOS Y CIMENTACIONES | 11d | 2025-03-22 | 2025-04-01 | A1940 | CAPATAZ; OPERARIO; OFICIAL [106.36 h]; PEON [425.43 h]; VOLQUETES; CISTERNA; CAMION GRUA BARANDA 3 TN; CARGADOR FRONTAL; EXCAVADORA SOBRE ORUGAS 180-348 HP; DUMPER DE DESCARGA FRONTA 2 TN; MOTONIVELADORA 145 -150HP; TRACTOR SOBREORUGAS 300-330HP; TRACTOR SOBREORUGAS 170-220HP; RETROEXCAVADORA; MIXER DE CONCRETO; RODILLO BERMERO; RODILLO LISO VIBR. AUTOPROPULSADO 101-135HP 10-12TN |
| 2 | **FASE 2 - TRAMOS CON RESTRICCION PREDIAL-1** |  | 2024-12-01 | 2025-04-13 |  |  |
| 2 | **MOVIMIENTO DE TIERRAS** |  | 2024-12-01 | 2025-04-13 |  |  |
| 1 | **PK 0+100 - PK 0+300** |  | 2024-12-01 | 2025-04-13 |  |  |
| A1910 | ELIMINACION DE MATERIAL EXCEDENTE (DME´S) | 0d | 2024-12-01 | 2024-12-01 |  | CAPATAZ; OPERARIO; OFICIAL; PEON; VOLQUETES; CISTERNA; CAMION GRUA BARANDA 3 TN; CARGADOR FRONTAL; EXCAVADORA SOBRE ORUGAS 180-348 HP; DUMPER DE DESCARGA FRONTA 2 TN; MOTONIVELADORA 145 -150HP; TRACTOR SOBREORUGAS 300-330HP; TRACTOR SOBREORUGAS 170-220HP; RETROEXCAVADORA; MIXER DE CONCRETO; RODILLO BERMERO; RODILLO LISO VIBR. AUTOPROPULSADO 101-135HP 10-12TN |
| A1870 | CORTE PARA CIMENTACIÓN DE DIQUE NATURALIZADO h=30cm | 10d | 2025-03-19 | 2025-03-28 | A1930, A1820 | CAPATAZ [95.14 h]; OPERARIO [95.14 h]; OFICIAL [95.14 h]; PEON [570.82 h]; VOLQUETES; CISTERNA; CAMION GRUA BARANDA 3 TN; CARGADOR FRONTAL; EXCAVADORA SOBRE ORUGAS 180-348 HP [95.14 h]; DUMPER DE DESCARGA FRONTA 2 TN; MOTONIVELADORA 145 -150HP; TRACTOR SOBREORUGAS 300-330HP; TRACTOR SOBREORUGAS 170-220HP; RETROEXCAVADORA; MIXER DE CONCRETO; RODILLO BERMERO; RODILLO LISO VIBR. AUTOPROPULSADO 101-135HP 10-12TN; EXCAVACION [6183.85] |
| A1880 | PERFILADO Y COMPACTACION EN ZONA DE CORTE | 4d | 2025-03-29 | 2025-04-01 | A1870 | CAPATAZ [3.93 h]; OPERARIO; OFICIAL [39.32 h]; PEON [39.32 h]; VOLQUETES; CISTERNA [39.32 h]; CAMION GRUA BARANDA 3 TN; CARGADOR FRONTAL; EXCAVADORA SOBRE ORUGAS 180-348 HP [39.32 h]; DUMPER DE DESCARGA FRONTA 2 TN; MOTONIVELADORA 145 -150HP [39.32 h]; TRACTOR SOBREORUGAS 300-330HP; TRACTOR SOBREORUGAS 170-220HP [19.66 h]; RETROEXCAVADORA; MIXER DE CONCRETO; RODILLO BERMERO; RODILLO LISO VIBR. AUTOPROPULSADO 101-135HP 10-12TN [39.32 h]; PERFILADO [11797.2] |
| A1890 | CONFORMACIÓN DE DIQUE NATURALIZADO O TERRAZA CON RELLENO COMPACTADO | 3d | 2025-04-02 | 2025-04-04 | A1880, A1000 FF, A1010 FF | CAPATAZ [2.14 h]; OPERARIO [21.4 h]; OFICIAL [21.4 h]; PEON [42.8 h]; VOLQUETES; CISTERNA [21.4 h]; CAMION GRUA BARANDA 3 TN; CARGADOR FRONTAL [5.35 h]; EXCAVADORA SOBRE ORUGAS 180-348 HP; DUMPER DE DESCARGA FRONTA 2 TN; MOTONIVELADORA 145 -150HP [21.4 h]; TRACTOR SOBREORUGAS 300-330HP; TRACTOR SOBREORUGAS 170-220HP; RETROEXCAVADORA; MIXER DE CONCRETO; RODILLO BERMERO; RODILLO LISO VIBR. AUTOPROPULSADO 101-135HP 10-12TN [21.4 h]; RELLENOS [1069.97] |
| A1900 | EXCAVACIÓN MANUAL PARA INSTALACIÓN DE BORDILLOS Y CIMENTACIONES | 9d | 2025-04-05 | 2025-04-13 | A1890, A1020 FF, A1030 FF | CAPATAZ; OPERARIO; OFICIAL [40.83 h]; PEON [163.31 h]; VOLQUETES; CISTERNA; CAMION GRUA BARANDA 3 TN; CARGADOR FRONTAL; EXCAVADORA SOBRE ORUGAS 180-348 HP; DUMPER DE DESCARGA FRONTA 2 TN; MOTONIVELADORA 145 -150HP; TRACTOR SOBREORUGAS 300-330HP; TRACTOR SOBREORUGAS 170-220HP; RETROEXCAVADORA; MIXER DE CONCRETO; RODILLO BERMERO; RODILLO LISO VIBR. AUTOPROPULSADO 101-135HP 10-12TN |
| 5 | **OBRAS PRELIMINARES PAISAJISMO** |  | 2025-05-19 | 2025-06-23 |  |  |

Removed: ARQUITECTURA Y PAISAJISMO; INTERVENCIÓN PAISAJISMO - HUMEDAL VILLA MARIA MARGEN DERECHO; OBRAS PRELIMINARES PAISAJISMO); OBRAS PRELIMINARES

Changed:

| ID | Task | Start | Finish | Duration | Total float | Predecessors | Other |
| --- | --- | --- | --- | --- | --- | --- | --- |
| A1000 | TRANSPORTE DE MATERIAL GRANULAR PARA DISTANCIAS <1KM | 2024-04-16 → 2024-12-19 (+247d) | 2024-04-25 → 2025-04-04 (+344d) | 9d → 107d | 0d → 71d | none → A1710 SS | was named INSTALACIONES PROVISIONALES PARA LA OBRA; resources none → CAPATAZ; OPERARIO [589.08 h]; OFICIAL; PEON [294.54 h]; VOLQUETES [589.08 h]; CISTERNA; CAMION GRUA BARANDA 3 TN; CARGADOR FRONTAL; EXCAVADORA SOBRE ORUGAS 180-348 HP [147.27 h]; DUMPER DE DESCARGA FRONTA 2 TN; MOTONIVELADORA 145 -150HP; TRACTOR SOBREORUGAS 300-330HP; TRACTOR SOBREORUGAS 170-220HP; RETROEXCAVADORA; MIXER DE CONCRETO; RODILLO BERMERO; RODILLO LISO VIBR. AUTOPROPULSADO 101-135HP 10-12TN |
| 1 | **OBRAS PRELIMINARES** | 2024-04-16 → 2024-12-01 (+229d) | 2024-04-25 → 2025-03-19 (+328d) |  |  |  |  |
| A1040 | MOVILIZACIÓN Y DEMOVILIZACIÓN DE EQUIPOS Y HERRAMIENTAS (ARQUITECTURA Y PAISAJISMO) | 2024-04-16 → 2024-12-01 (+229d) | 2024-05-02 → 2024-12-16 (+228d) | 15d → 16d | 17d → 0d | A1000 SS → H1000 SS | resources none → CAPATAZ; OPERARIO; OFICIAL; PEON; VOLQUETES; CISTERNA; CAMION GRUA BARANDA 3 TN; CARGADOR FRONTAL; EXCAVADORA SOBRE ORUGAS 180-348 HP; DUMPER DE DESCARGA FRONTA 2 TN; MOTONIVELADORA 145 -150HP; TRACTOR SOBREORUGAS 300-330HP; TRACTOR SOBREORUGAS 170-220HP; RETROEXCAVADORA; MIXER DE CONCRETO; RODILLO BERMERO; RODILLO LISO VIBR. AUTOPROPULSADO 101-135HP 10-12TN |
| A1050 | TRAZO Y REPLANTEO PRELIMINAR | 2024-05-03 → 2024-12-08 (+219d) | 2024-10-24 → 2025-01-07 (+75d) | 150d → 31d | 17d → 9d | A1000, A1040 → H1000 SS+7d | resources none → CAPATAZ; OPERARIO [603.41 h]; OFICIAL [603.41 h]; PEON [1206.81 h]; VOLQUETES; CISTERNA; CAMION GRUA BARANDA 3 TN; CARGADOR FRONTAL; EXCAVADORA SOBRE ORUGAS 180-348 HP; DUMPER DE DESCARGA FRONTA 2 TN; MOTONIVELADORA 145 -150HP; TRACTOR SOBREORUGAS 300-330HP; TRACTOR SOBREORUGAS 170-220HP; RETROEXCAVADORA; MIXER DE CONCRETO; RODILLO BERMERO; RODILLO LISO VIBR. AUTOPROPULSADO 101-135HP 10-12TN |
| A1060 | ELIMINACION DE RESIDUOS SOLIDOS GENERALES MUNICIPALES | 2024-04-26 → 2024-12-19 (+237d) | 2024-07-11 → 2025-03-19 (+251d) | 66d → 91d | 0d → 81d | A1000 → A1690 | resources none → CAPATAZ [362.19 h]; OPERARIO [362.19 h]; OFICIAL [1810.93 h]; PEON [3621.86 h]; VOLQUETES [3621.86 h]; CISTERNA; CAMION GRUA BARANDA 3 TN; CARGADOR FRONTAL; EXCAVADORA SOBRE ORUGAS 180-348 HP [3621.86 h]; DUMPER DE DESCARGA FRONTA 2 TN; MOTONIVELADORA 145 -150HP; TRACTOR SOBREORUGAS 300-330HP [1810.93 h]; TRACTOR SOBREORUGAS 170-220HP; RETROEXCAVADORA; MIXER DE CONCRETO; RODILLO BERMERO; RODILLO LISO VIBR. AUTOPROPULSADO 101-135HP 10-12TN; EXCAVACION [63382.6] |
| 2 | **MOVIMIENTO DE TIERRAS** | 2024-06-26 → 2024-12-01 (+158d) | 2024-10-29 → 2025-02-23 (+117d) |  |  |  |  |
| A1740 | ELIMINACION DE MATERIAL EXCEDENTE (DME´S) | 2024-10-12 → 2024-12-01 (+50d) | 2024-10-29 → 2024-12-01 (+33d) | 15d → 0d | 13d → 205d | A1690, A1720, A1730 → none |  |
| A1690 | CORTE PARA CIMENTACIÓN DE DIQUE NATURALIZADO h=30cm | 2024-06-26 → 2024-12-17 (+174d) | 2024-07-12 → 2024-12-18 (+159d) | 15d → 2d |  | A1060 SS+52d, A1050 SS+1d → A1040, A1050 SS | resources none → CAPATAZ [16.71 h]; OPERARIO [16.71 h]; OFICIAL [16.71 h]; PEON [100.26 h]; VOLQUETES; CISTERNA; CAMION GRUA BARANDA 3 TN; CARGADOR FRONTAL; EXCAVADORA SOBRE ORUGAS 180-348 HP [16.71 h]; DUMPER DE DESCARGA FRONTA 2 TN; MOTONIVELADORA 145 -150HP; TRACTOR SOBREORUGAS 300-330HP; TRACTOR SOBREORUGAS 170-220HP; RETROEXCAVADORA; MIXER DE CONCRETO; RODILLO BERMERO; RODILLO LISO VIBR. AUTOPROPULSADO 101-135HP 10-12TN; EXCAVACION [1086.2] |
| A1700 | PERFILADO Y COMPACTACION EN ZONA DE CORTE | 2024-07-03 → 2024-12-17 (+167d) | 2024-07-16 → 2024-12-18 (+155d) | 12d → 2d |  | A1690 SS+6d → A1690 SS | resources none → CAPATAZ [1.84 h]; OPERARIO; OFICIAL [18.37 h]; PEON [18.37 h]; VOLQUETES; CISTERNA [18.37 h]; CAMION GRUA BARANDA 3 TN; CARGADOR FRONTAL; EXCAVADORA SOBRE ORUGAS 180-348 HP [18.37 h]; DUMPER DE DESCARGA FRONTA 2 TN; MOTONIVELADORA 145 -150HP [18.37 h]; TRACTOR SOBREORUGAS 300-330HP; TRACTOR SOBREORUGAS 170-220HP [9.19 h]; RETROEXCAVADORA; MIXER DE CONCRETO; RODILLO BERMERO; RODILLO LISO VIBR. AUTOPROPULSADO 101-135HP 10-12TN [18.37 h]; PERFILADO [5512.24] |
| A1710 | CONFORMACIÓN DE CUERPO DE DIQUE NATURALZADO CON RELLENO COMPACTADO | 2024-07-17 → 2024-12-19 (+155d) | 2024-08-28 → 2024-12-24 (+118d) | 37d → 6d |  | A1700, A1060 → A1700 | resources none → CAPATAZ [5.85 h]; OPERARIO [58.47 h]; OFICIAL [58.47 h]; PEON [116.94 h]; VOLQUETES; CISTERNA [58.47 h]; CAMION GRUA BARANDA 3 TN; CARGADOR FRONTAL [14.62 h]; EXCAVADORA SOBRE ORUGAS 180-348 HP; DUMPER DE DESCARGA FRONTA 2 TN; MOTONIVELADORA 145 -150HP [58.47 h]; TRACTOR SOBREORUGAS 300-330HP; TRACTOR SOBREORUGAS 170-220HP; RETROEXCAVADORA; MIXER DE CONCRETO; RODILLO BERMERO; RODILLO LISO VIBR. AUTOPROPULSADO 101-135HP 10-12TN [58.47 h]; RELLENOS [2923.57] |
| A1720 | EXCAVACIÓN MANUAL PARA INSTALACIÓN DE BORDILLOS Y CIMENTACIONES | 2024-08-29 → 2024-12-25 (+118d) | 2024-10-11 → 2025-01-07 (+88d) | 38d → 14d | 4d → 0d |  | resources none → CAPATAZ; OPERARIO; OFICIAL [68.31 h]; PEON [273.25 h]; VOLQUETES; CISTERNA; CAMION GRUA BARANDA 3 TN; CARGADOR FRONTAL; EXCAVADORA SOBRE ORUGAS 180-348 HP; DUMPER DE DESCARGA FRONTA 2 TN; MOTONIVELADORA 145 -150HP; TRACTOR SOBREORUGAS 300-330HP; TRACTOR SOBREORUGAS 170-220HP; RETROEXCAVADORA; MIXER DE CONCRETO; RODILLO BERMERO; RODILLO LISO VIBR. AUTOPROPULSADO 101-135HP 10-12TN |
| A1730 | EXCAVACIÓN PARA MEJORAMIENTO DE SUELO CON TIERRA VEGETAL | 2024-08-29 → 2025-02-19 (+174d) | 2024-08-30 → 2025-02-19 (+173d) | 2d → 1d | 49d → 8d | A1710 → A1720, A1820 | resources none → CAPATAZ [0.03 h]; OPERARIO [0.27 h]; OFICIAL [0.13 h]; PEON [0.27 h]; VOLQUETES; CISTERNA; CAMION GRUA BARANDA 3 TN; CARGADOR FRONTAL; EXCAVADORA SOBRE ORUGAS 180-348 HP [0.27 h]; DUMPER DE DESCARGA FRONTA 2 TN; MOTONIVELADORA 145 -150HP; TRACTOR SOBREORUGAS 300-330HP [0.13 h]; TRACTOR SOBREORUGAS 170-220HP; RETROEXCAVADORA; MIXER DE CONCRETO; RODILLO BERMERO; RODILLO LISO VIBR. AUTOPROPULSADO 101-135HP 10-12TN |
| A1750 | CORTE PARA CIMENTACIÓN DE DIQUE NATURALIZADO h=30cm | 2024-06-04 → 2024-12-19 (+198d) | 2024-07-13 → 2024-12-21 (+161d) | 35d → 3d | 0d → 3d | A1250 SS+33d → A1690 | resources none → CAPATAZ [27.74 h]; OPERARIO [27.74 h]; OFICIAL [27.74 h]; PEON [166.44 h]; VOLQUETES; CISTERNA; CAMION GRUA BARANDA 3 TN; CARGADOR FRONTAL; EXCAVADORA SOBRE ORUGAS 180-348 HP [27.74 h]; DUMPER DE DESCARGA FRONTA 2 TN; MOTONIVELADORA 145 -150HP; TRACTOR SOBREORUGAS 300-330HP; TRACTOR SOBREORUGAS 170-220HP; RETROEXCAVADORA; MIXER DE CONCRETO; RODILLO BERMERO; RODILLO LISO VIBR. AUTOPROPULSADO 101-135HP 10-12TN; EXCAVACION [1803.09] |
| A1760 | PERFILADO Y COMPACTACION EN ZONA DE CORTE | 2024-07-09 → 2024-12-22 (+166d) | 2024-07-24 → 2024-12-25 (+154d) | 14d → 4d | 0d → 3d | A1750 SS+30d → A1750, A1700 | resources none → CAPATAZ [3.05 h]; OPERARIO; OFICIAL [30.5 h]; PEON [30.5 h]; VOLQUETES; CISTERNA [30.5 h]; CAMION GRUA BARANDA 3 TN; CARGADOR FRONTAL; EXCAVADORA SOBRE ORUGAS 180-348 HP [30.5 h]; DUMPER DE DESCARGA FRONTA 2 TN; MOTONIVELADORA 145 -150HP [30.5 h]; TRACTOR SOBREORUGAS 300-330HP; TRACTOR SOBREORUGAS 170-220HP [15.25 h]; RETROEXCAVADORA; MIXER DE CONCRETO; RODILLO BERMERO; RODILLO LISO VIBR. AUTOPROPULSADO 101-135HP 10-12TN [30.5 h]; RELLENOS [9150.32] |
| A1780 | EXCAVACIÓN MANUAL PARA INSTALACIÓN DE BORDILLOS Y CIMENTACIONES | 2024-07-31 → 2025-01-08 (+161d) | 2024-08-13 → 2025-01-19 (+159d) |  | 44d → 0d | A1280 → A1770, A1720 | resources none → CAPATAZ; OPERARIO; OFICIAL [113.4 h]; PEON [453.6 h]; VOLQUETES; CISTERNA; CAMION GRUA BARANDA 3 TN; CARGADOR FRONTAL; EXCAVADORA SOBRE ORUGAS 180-348 HP; DUMPER DE DESCARGA FRONTA 2 TN; MOTONIVELADORA 145 -150HP; TRACTOR SOBREORUGAS 300-330HP; TRACTOR SOBREORUGAS 170-220HP; RETROEXCAVADORA; MIXER DE CONCRETO; RODILLO BERMERO; RODILLO LISO VIBR. AUTOPROPULSADO 101-135HP 10-12TN |
| 2 | **MOVIMIENTO DE TIERRAS** | 2024-06-04 → 2024-12-01 (+180d) | 2024-10-18 → 2025-04-03 (+167d) |  |  |  |  |
| A1860 | ELIMINACION DE MATERIAL EXCEDENTE (DME´S) | 2024-09-09 → 2024-12-01 (+83d) | 2024-10-18 → 2024-12-01 (+44d) | 35d → 0d | 22d → 205d | A1780, A1750, A1310 → none | resources none → CAPATAZ; OPERARIO; OFICIAL; PEON; VOLQUETES; CISTERNA; CAMION GRUA BARANDA 3 TN; CARGADOR FRONTAL; EXCAVADORA SOBRE ORUGAS 180-348 HP; DUMPER DE DESCARGA FRONTA 2 TN; MOTONIVELADORA 145 -150HP; TRACTOR SOBREORUGAS 300-330HP; TRACTOR SOBREORUGAS 170-220HP; RETROEXCAVADORA; MIXER DE CONCRETO; RODILLO BERMERO; RODILLO LISO VIBR. AUTOPROPULSADO 101-135HP 10-12TN |
| 3 | **PAVIMENTOS, RECUBRIMIENTOS Y BORDILLOS** | 2024-10-03 → 2025-01-20 (+109d) | 2024-11-12 → 2025-05-04 (+173d) |  |  |  |  |
| A1490 | BORDILLOS DE PIEDRA DEL LUGAR | 2024-10-21 → 2025-01-20 (+91d) | 2024-11-12 → 2025-02-26 (+106d) | 20d → 38d | 1d → 35d | A1470 SS+15d, A1720 → A1780 | resources none → CAPATAZ [747.8 h]; OPERARIO [1495.6 h]; OFICIAL [3739 h]; PEON [7478 h]; VOLQUETES; CISTERNA; CAMION GRUA BARANDA 3 TN; CARGADOR FRONTAL; EXCAVADORA SOBRE ORUGAS 180-348 HP; DUMPER DE DESCARGA FRONTA 2 TN; MOTONIVELADORA 145 -150HP; TRACTOR SOBREORUGAS 300-330HP; TRACTOR SOBREORUGAS 170-220HP; RETROEXCAVADORA; MIXER DE CONCRETO; RODILLO BERMERO; RODILLO LISO VIBR. AUTOPROPULSADO 101-135HP 10-12TN; BORDILLOS [7478] |
| A1470 | PISO TIERRA APISONADA (h=0.35cm) | 2024-10-03 → 2025-04-03 (+182d) | 2024-11-06 → 2025-04-30 (+175d) | 30d → 28d |  | A1560 → A1490, A1600, A1850 SS | resources none → CAPATAZ [107.28 h]; OPERARIO [107.28 h]; OFICIAL [107.28 h]; PEON [2145.55 h]; VOLQUETES; CISTERNA [536.39 h]; CAMION GRUA BARANDA 3 TN; CARGADOR FRONTAL; EXCAVADORA SOBRE ORUGAS 180-348 HP; DUMPER DE DESCARGA FRONTA 2 TN [1072.77 h]; MOTONIVELADORA 145 -150HP; TRACTOR SOBREORUGAS 300-330HP; TRACTOR SOBREORUGAS 170-220HP; RETROEXCAVADORA; MIXER DE CONCRETO [1072.77 h]; RODILLO BERMERO [1072.77 h]; RODILLO LISO VIBR. AUTOPROPULSADO 101-135HP 10-12TN; TIERRA APISONADA [21455.5] |
| A1480 | RECUBRIMIENTO DE PIEDRA DEL LUGAR e=0.05cm | 2024-10-21 → 2025-05-01 (+192d) | 2024-10-31 → 2025-05-04 (+185d) | 10d → 4d | 11d → 0d | A1470 SS+15d, A1720 → A1470 | resources none → CAPATAZ [3.13 h]; OPERARIO [31.33 h]; OFICIAL [94 h]; PEON [250.67 h]; VOLQUETES [31.33 h]; CISTERNA [15.67 h]; CAMION GRUA BARANDA 3 TN; CARGADOR FRONTAL; EXCAVADORA SOBRE ORUGAS 180-348 HP; DUMPER DE DESCARGA FRONTA 2 TN; MOTONIVELADORA 145 -150HP; TRACTOR SOBREORUGAS 300-330HP; TRACTOR SOBREORUGAS 170-220HP; RETROEXCAVADORA [31.33 h]; MIXER DE CONCRETO; RODILLO BERMERO; RODILLO LISO VIBR. AUTOPROPULSADO 101-135HP 10-12TN |
| 4 | **MOBILIARIOS, BARANDAS Y ESCALERAS** | 2024-10-17 → 2025-05-05 (+200d) | 2024-11-13 → 2025-05-20 (+188d) |  |  |  |  |
| A1520 | POSTES DE ILUMINACION, INCLUYE LUMINARIA Y CIMENTACION | 2024-10-21 → 2025-05-05 (+196d) | 2024-11-12 → 2025-05-07 (+176d) | 20d → 3d | 1d → 0d | A1720, A1470 SS+15d → A1480 | resources none → CAPATAZ [11.88 h]; OPERARIO [2.38 h]; OFICIAL [2.38 h]; PEON [23.75 h]; VOLQUETES; CISTERNA [0.59 h]; CAMION GRUA BARANDA 3 TN; CARGADOR FRONTAL; EXCAVADORA SOBRE ORUGAS 180-348 HP; DUMPER DE DESCARGA FRONTA 2 TN; MOTONIVELADORA 145 -150HP; TRACTOR SOBREORUGAS 300-330HP; TRACTOR SOBREORUGAS 170-220HP; RETROEXCAVADORA; MIXER DE CONCRETO; RODILLO BERMERO; RODILLO LISO VIBR. AUTOPROPULSADO 101-135HP 10-12TN |
| A1530 | SEÑALETICA INFORMATIVA | 2024-10-21 → 2025-05-05 (+196d) | 2024-10-31 → 2025-05-11 (+192d) | 10d → 7d | 11d → 0d | A1720, A1470 SS+15d → A1520 SS | resources none → CAPATAZ; OPERARIO; OFICIAL; PEON; VOLQUETES; CISTERNA; CAMION GRUA BARANDA 3 TN; CARGADOR FRONTAL; EXCAVADORA SOBRE ORUGAS 180-348 HP; DUMPER DE DESCARGA FRONTA 2 TN; MOTONIVELADORA 145 -150HP; TRACTOR SOBREORUGAS 300-330HP; TRACTOR SOBREORUGAS 170-220HP; RETROEXCAVADORA; MIXER DE CONCRETO; RODILLO BERMERO; RODILLO LISO VIBR. AUTOPROPULSADO 101-135HP 10-12TN |
| A1500 | TACHOS DE BASURA, INCLUYE CIMENTACIÓN | 2024-10-21 → 2025-05-12 (+203d) | 2024-11-12 → 2025-05-13 (+182d) | 20d → 1.6d | 1d → 41.4d | A1720, A1470 SS+15d → A1530 | resources none → CAPATAZ [7.92 h]; OPERARIO [15.83 h]; OFICIAL [1.58 h]; PEON [63.33 h]; VOLQUETES; CISTERNA [7.92 h]; CAMION GRUA BARANDA 3 TN; CARGADOR FRONTAL; EXCAVADORA SOBRE ORUGAS 180-348 HP; DUMPER DE DESCARGA FRONTA 2 TN; MOTONIVELADORA 145 -150HP; TRACTOR SOBREORUGAS 300-330HP; TRACTOR SOBREORUGAS 170-220HP; RETROEXCAVADORA; MIXER DE CONCRETO; RODILLO BERMERO; RODILLO LISO VIBR. AUTOPROPULSADO 101-135HP 10-12TN |
| A1510 | BANCAS DE CONCRETO, INCLUYE CIMENTACIÓN | 2024-10-21 → 2025-05-12 (+203d) | 2024-11-06 → 2025-05-16 (+191d) | 15d → 5d | 6d → 34d | A1720, A1470 SS+15d → A1520, A1530 | resources none → CAPATAZ [23.75 h]; OPERARIO [47.5 h]; OFICIAL [4.75 h]; PEON [190 h]; VOLQUETES; CISTERNA [1.19 h]; CAMION GRUA BARANDA 3 TN; CARGADOR FRONTAL; EXCAVADORA SOBRE ORUGAS 180-348 HP; DUMPER DE DESCARGA FRONTA 2 TN; MOTONIVELADORA 145 -150HP; TRACTOR SOBREORUGAS 300-330HP; TRACTOR SOBREORUGAS 170-220HP; RETROEXCAVADORA; MIXER DE CONCRETO; RODILLO BERMERO; RODILLO LISO VIBR. AUTOPROPULSADO 101-135HP 10-12TN |
| A1550 | TRANQUERA | 2024-10-21 → 2025-05-12 (+203d) | 2024-11-06 → 2025-05-13 (+188d) | 15d → 2d | 6d → 41d | A1720, A1470 SS+15d → A1530 | resources none → CAPATAZ [1.5 h]; OPERARIO [7.5 h]; OFICIAL [15 h]; PEON [60 h]; VOLQUETES; CISTERNA [0.38 h]; CAMION GRUA BARANDA 3 TN; CARGADOR FRONTAL; EXCAVADORA SOBRE ORUGAS 180-348 HP; DUMPER DE DESCARGA FRONTA 2 TN; MOTONIVELADORA 145 -150HP; TRACTOR SOBREORUGAS 300-330HP; TRACTOR SOBREORUGAS 170-220HP; RETROEXCAVADORA; MIXER DE CONCRETO; RODILLO BERMERO; RODILLO LISO VIBR. AUTOPROPULSADO 101-135HP 10-12TN |
| A1540 | BOLARDOS DE PIEDRA | 2024-10-17 → 2025-05-17 (+212d) | 2024-11-13 → 2025-05-20 (+188d) | 24d → 4d | 0d → 34d | A1720, A1470 SS+12d → A1520, A1510 | resources none → CAPATAZ [3.83 h]; OPERARIO [3.83 h]; OFICIAL [38.25 h]; PEON [382.5 h]; VOLQUETES [19.12 h]; CISTERNA; CAMION GRUA BARANDA 3 TN; CARGADOR FRONTAL; EXCAVADORA SOBRE ORUGAS 180-348 HP; DUMPER DE DESCARGA FRONTA 2 TN; MOTONIVELADORA 145 -150HP; TRACTOR SOBREORUGAS 300-330HP; TRACTOR SOBREORUGAS 170-220HP; RETROEXCAVADORA [19.12 h]; MIXER DE CONCRETO; RODILLO BERMERO; RODILLO LISO VIBR. AUTOPROPULSADO 101-135HP 10-12TN |
| 8 | **OBRAS PRELIMINARES PAISAJISMO** | 2024-07-31 → 2025-05-05 (+278d) | 2024-08-24 → 2025-06-12 (+292d) |  |  |  |  |
| A1560 | MEJORAMIENTO DE SUELO CON TIERRA DE CHACRA (incluye despedregado y rastrillado) | 2024-08-29 → 2025-05-05 (+249d) | 2024-10-02 → 2025-06-12 (+253d) | 30d → 39d | 0d → 11d | A1710 → A1480 | resources none → CAPATAZ [38.54 h]; OPERARIO [770.87 h]; OFICIAL [1541.74 h]; PEON [3854.36 h]; VOLQUETES; CISTERNA [192.72 h]; CAMION GRUA BARANDA 3 TN [192.72 h]; CARGADOR FRONTAL; EXCAVADORA SOBRE ORUGAS 180-348 HP; DUMPER DE DESCARGA FRONTA 2 TN; MOTONIVELADORA 145 -150HP [192.72 h]; TRACTOR SOBREORUGAS 300-330HP; TRACTOR SOBREORUGAS 170-220HP; RETROEXCAVADORA; MIXER DE CONCRETO; RODILLO BERMERO; RODILLO LISO VIBR. AUTOPROPULSADO 101-135HP 10-12TN |
| 5 | **INTERVENCIÓN PAISAJISMO - HUMEDAL VILLA MARIA MARGEN IZQUIERDO** | 2024-04-16 → 2024-12-01 (+229d) | 2024-11-13 → 2025-06-23 (+222d) |  |  |  |  |
| 1 | **OBRAS PRELIMINARES** | 2024-04-16 → 2024-12-01 (+229d) | 2024-10-24 → 2025-05-07 (+195d) |  |  |  |  |
| A1230 | MOVILIZACIÓN Y DEMOVILIZACIÓN DE EQUIPOS Y HERRAMIENTAS (ARQUITECTURA Y PAISAJISMO) | 2024-04-16 → 2024-12-01 (+229d) | 2024-05-02 → 2024-12-16 (+228d) | 15d → 16d | 166d → 53d | A1040 SS → H1000 SS | resources none → CAPATAZ; OPERARIO; OFICIAL; PEON; VOLQUETES; CISTERNA; CAMION GRUA BARANDA 3 TN; CARGADOR FRONTAL; EXCAVADORA SOBRE ORUGAS 180-348 HP; DUMPER DE DESCARGA FRONTA 2 TN; MOTONIVELADORA 145 -150HP; TRACTOR SOBREORUGAS 300-330HP; TRACTOR SOBREORUGAS 170-220HP; RETROEXCAVADORA; MIXER DE CONCRETO; RODILLO BERMERO; RODILLO LISO VIBR. AUTOPROPULSADO 101-135HP 10-12TN |
| A1240 | TRAZO Y REPLANTEO PRELIMINAR | 2024-05-03 → 2025-01-08 (+250d) | 2024-05-03 → 2025-02-01 (+274d) | 1d → 25d | 166d → 31d | A1000, A1230 → A1050, A1230 | resources none → CAPATAZ; OPERARIO [484.28 h]; OFICIAL [484.28 h]; PEON [968.55 h]; VOLQUETES; CISTERNA; CAMION GRUA BARANDA 3 TN; CARGADOR FRONTAL; EXCAVADORA SOBRE ORUGAS 180-348 HP; DUMPER DE DESCARGA FRONTA 2 TN; MOTONIVELADORA 145 -150HP; TRACTOR SOBREORUGAS 300-330HP; TRACTOR SOBREORUGAS 170-220HP; RETROEXCAVADORA; MIXER DE CONCRETO; RODILLO BERMERO; RODILLO LISO VIBR. AUTOPROPULSADO 101-135HP 10-12TN |
| A1250 | ELIMINACION DE RESIDUOS SOLIDOS GENERALES MUNICIPALES | 2024-04-26 → 2025-02-27 (+307d) | 2024-06-20 → 2025-05-07 (+321d) | 48d → 70d | 0d → 11d | A1000 → A1060 SS, A1260 | resources none → CAPATAZ [278.32 h]; OPERARIO [278.32 h]; OFICIAL [1391.6 h]; PEON [2783.19 h]; VOLQUETES [2783.19 h]; CISTERNA; CAMION GRUA BARANDA 3 TN; CARGADOR FRONTAL; EXCAVADORA SOBRE ORUGAS 180-348 HP [2783.19 h]; DUMPER DE DESCARGA FRONTA 2 TN; MOTONIVELADORA 145 -150HP; TRACTOR SOBREORUGAS 300-330HP [1391.6 h]; TRACTOR SOBREORUGAS 170-220HP; RETROEXCAVADORA; MIXER DE CONCRETO; RODILLO BERMERO; RODILLO LISO VIBR. AUTOPROPULSADO 101-135HP 10-12TN; EXCAVACION [48705.9] |
| A1280 | CONFORMACIÓN DE DIQUE NATURALIZADO O TERRAZA CON RELLENO COMPACTADO | 2024-07-25 → 2025-02-28 (+218d) | 2024-07-30 → 2025-02-28 (+213d) | 5d → 1d | 0d → 112d | A1760, A1250, A1690 → A1270 | resources none → CAPATAZ [1.07 h]; OPERARIO [10.7 h]; OFICIAL [10.7 h]; PEON [21.4 h]; VOLQUETES; CISTERNA [10.7 h]; CAMION GRUA BARANDA 3 TN; CARGADOR FRONTAL [2.67 h]; EXCAVADORA SOBRE ORUGAS 180-348 HP; DUMPER DE DESCARGA FRONTA 2 TN; MOTONIVELADORA 145 -150HP [10.7 h]; TRACTOR SOBREORUGAS 300-330HP; TRACTOR SOBREORUGAS 170-220HP; RETROEXCAVADORA; MIXER DE CONCRETO; RODILLO BERMERO; RODILLO LISO VIBR. AUTOPROPULSADO 101-135HP 10-12TN [10.7 h]; RELLENOS [534.98] |
| 3 | **PAVIMENTOS, RECUBRIMIENTOS Y BORDILLOS** | 2024-08-26 → 2025-04-02 (+219d) | 2024-10-01 → 2025-05-02 (+213d) |  |  |  |  |
| A1330 | BORDILLOS DE PIEDRA DEL LUGAR | 2024-09-09 → 2025-04-02 (+205d) | 2024-10-01 → 2025-04-10 (+191d) | 20d → 9d | 37d → 9d | A1310 → A1950 | resources none → CAPATAZ [167.6 h]; OPERARIO [335.2 h]; OFICIAL [838 h]; PEON [1676 h]; VOLQUETES; CISTERNA; CAMION GRUA BARANDA 3 TN; CARGADOR FRONTAL; EXCAVADORA SOBRE ORUGAS 180-348 HP; DUMPER DE DESCARGA FRONTA 2 TN; MOTONIVELADORA 145 -150HP; TRACTOR SOBREORUGAS 300-330HP; TRACTOR SOBREORUGAS 170-220HP; RETROEXCAVADORA; MIXER DE CONCRETO; RODILLO BERMERO; RODILLO LISO VIBR. AUTOPROPULSADO 101-135HP 10-12TN; BORDILLOS [1676] |
| A1310 | PISO TIERRA APISONADA (h=0.35cm) | 2024-08-26 → 2025-04-11 (+228d) | 2024-09-07 → 2025-04-30 (+235d) | 12d → 20d | 0d → 9d | A1400 → A1330 | resources none → CAPATAZ [39.72 h]; OPERARIO [39.72 h]; OFICIAL [39.72 h]; PEON [794.35 h]; VOLQUETES; CISTERNA [198.59 h]; CAMION GRUA BARANDA 3 TN; CARGADOR FRONTAL; EXCAVADORA SOBRE ORUGAS 180-348 HP; DUMPER DE DESCARGA FRONTA 2 TN [397.18 h]; MOTONIVELADORA 145 -150HP; TRACTOR SOBREORUGAS 300-330HP; TRACTOR SOBREORUGAS 170-220HP; RETROEXCAVADORA; MIXER DE CONCRETO [397.18 h]; RODILLO BERMERO [397.18 h]; RODILLO LISO VIBR. AUTOPROPULSADO 101-135HP 10-12TN; TIERRA APISONADA [7943.53] |
| A1320 | RECUBRIMIENTO DE PIEDRA DEL LUGAR e=0.05cm | 2024-09-09 → 2025-05-01 (+234d) | 2024-09-16 → 2025-05-02 (+228d) | 7d → 2d | 50d → 9d |  | resources none → CAPATAZ [1.61 h]; OPERARIO [16.05 h]; OFICIAL [48.16 h]; PEON [128.43 h]; VOLQUETES [16.05 h]; CISTERNA [8.03 h]; CAMION GRUA BARANDA 3 TN; CARGADOR FRONTAL; EXCAVADORA SOBRE ORUGAS 180-348 HP; DUMPER DE DESCARGA FRONTA 2 TN; MOTONIVELADORA 145 -150HP; TRACTOR SOBREORUGAS 300-330HP; TRACTOR SOBREORUGAS 170-220HP; RETROEXCAVADORA [16.05 h]; MIXER DE CONCRETO; RODILLO BERMERO; RODILLO LISO VIBR. AUTOPROPULSADO 101-135HP 10-12TN |
| 4 | **MOBILIARIOS, BARANDAS Y ESCALERAS** | 2024-08-31 → 2025-05-12 (+254d) | 2024-11-13 → 2025-05-29 (+197d) |  |  |  |  |
| A1360 | POSTES DE ILUMINACION, INCLUYE LUMINARIA Y CIMENTACION | 2024-08-31 → 2025-05-12 (+254d) | 2024-09-28 → 2025-05-12 (+226d) | 25d → 1d | 39d → 0d | A1310 SS+5d → A1320, A1530 | resources none → CAPATAZ [3.12 h]; OPERARIO [0.62 h]; OFICIAL [0.62 h]; PEON [6.25 h]; VOLQUETES; CISTERNA [0.16 h]; CAMION GRUA BARANDA 3 TN; CARGADOR FRONTAL; EXCAVADORA SOBRE ORUGAS 180-348 HP; DUMPER DE DESCARGA FRONTA 2 TN; MOTONIVELADORA 145 -150HP; TRACTOR SOBREORUGAS 300-330HP; TRACTOR SOBREORUGAS 170-220HP; RETROEXCAVADORA; MIXER DE CONCRETO; RODILLO BERMERO; RODILLO LISO VIBR. AUTOPROPULSADO 101-135HP 10-12TN |
| A1370 | SEÑALETICA INFORMATIVA | 2024-08-31 → 2025-05-13 (+255d) | 2024-09-11 → 2025-05-14 (+245d) | 10d → 2d | 54d → 0d | A1310 SS+5d → A1360 | resources none → CAPATAZ; OPERARIO; OFICIAL; PEON; VOLQUETES; CISTERNA; CAMION GRUA BARANDA 3 TN; CARGADOR FRONTAL; EXCAVADORA SOBRE ORUGAS 180-348 HP; DUMPER DE DESCARGA FRONTA 2 TN; MOTONIVELADORA 145 -150HP; TRACTOR SOBREORUGAS 300-330HP; TRACTOR SOBREORUGAS 170-220HP; RETROEXCAVADORA; MIXER DE CONCRETO; RODILLO BERMERO; RODILLO LISO VIBR. AUTOPROPULSADO 101-135HP 10-12TN |
| A1350 | BANCAS DE CONCRETO, INCLUYE CIMENTACIÓN | 2024-08-31 → 2025-05-15 (+257d) | 2024-09-17 → 2025-05-18 (+243d) | 15d → 4d | 49d → 0d | A1310 SS+5d → A1370 | resources none → CAPATAZ [17.5 h]; OPERARIO [35 h]; OFICIAL [3.5 h]; PEON [140 h]; VOLQUETES; CISTERNA [0.88 h]; CAMION GRUA BARANDA 3 TN; CARGADOR FRONTAL; EXCAVADORA SOBRE ORUGAS 180-348 HP; DUMPER DE DESCARGA FRONTA 2 TN; MOTONIVELADORA 145 -150HP; TRACTOR SOBREORUGAS 300-330HP; TRACTOR SOBREORUGAS 170-220HP; RETROEXCAVADORA; MIXER DE CONCRETO; RODILLO BERMERO; RODILLO LISO VIBR. AUTOPROPULSADO 101-135HP 10-12TN |
| A1380 | BOLARDOS DE PIEDRA | 2024-08-31 → 2025-05-19 (+261d) | 2024-11-13 → 2025-05-28 (+196d) | 64d → 10d | 0d → 25d | A1310 SS+5d → A1350 | resources none → CAPATAZ [19.3 h]; OPERARIO [19.3 h]; OFICIAL [193 h]; PEON [1930 h]; VOLQUETES [96.5 h]; CISTERNA; CAMION GRUA BARANDA 3 TN; CARGADOR FRONTAL; EXCAVADORA SOBRE ORUGAS 180-348 HP; DUMPER DE DESCARGA FRONTA 2 TN; MOTONIVELADORA 145 -150HP; TRACTOR SOBREORUGAS 300-330HP; TRACTOR SOBREORUGAS 170-220HP; RETROEXCAVADORA [96.5 h]; MIXER DE CONCRETO; RODILLO BERMERO; RODILLO LISO VIBR. AUTOPROPULSADO 101-135HP 10-12TN |
| A1340 | TACHOS DE BASURA, INCLUYE CIMENTACIÓN | 2024-08-31 → 2025-05-29 (+271d) | 2024-09-28 → 2025-05-29 (+243d) | 25d → 1d | 39d → 25d | A1310 SS+5d → A1390 SS | resources none → CAPATAZ [1.67 h]; OPERARIO [3.33 h]; OFICIAL [0.33 h]; PEON [13.33 h]; VOLQUETES; CISTERNA [1.67 h]; CAMION GRUA BARANDA 3 TN; CARGADOR FRONTAL; EXCAVADORA SOBRE ORUGAS 180-348 HP; DUMPER DE DESCARGA FRONTA 2 TN; MOTONIVELADORA 145 -150HP; TRACTOR SOBREORUGAS 300-330HP; TRACTOR SOBREORUGAS 170-220HP; RETROEXCAVADORA; MIXER DE CONCRETO; RODILLO BERMERO; RODILLO LISO VIBR. AUTOPROPULSADO 101-135HP 10-12TN |
| A1390 | TRANQUERA | 2024-08-31 → 2025-05-29 (+271d) | 2024-09-17 → 2025-05-29 (+254d) | 15d → 1d | 49d → 25d | A1310 SS+5d → A1380 | resources none → CAPATAZ [0.25 h]; OPERARIO [1.25 h]; OFICIAL [2.5 h]; PEON [10 h]; VOLQUETES; CISTERNA [0.06 h]; CAMION GRUA BARANDA 3 TN; CARGADOR FRONTAL; EXCAVADORA SOBRE ORUGAS 180-348 HP; DUMPER DE DESCARGA FRONTA 2 TN; MOTONIVELADORA 145 -150HP; TRACTOR SOBREORUGAS 300-330HP; TRACTOR SOBREORUGAS 170-220HP; RETROEXCAVADORA; MIXER DE CONCRETO; RODILLO BERMERO; RODILLO LISO VIBR. AUTOPROPULSADO 101-135HP 10-12TN |
| A1400 | MEJORAMIENTO DE SUELO CON TIERRA DE CHACRA (incluye despedregado y rastrillado) | 2024-07-31 → 2025-05-19 (+292d) | 2024-08-24 → 2025-06-23 (+303d) | 22d → 36d |  | A1280 → A1350, A1250 | resources none → CAPATAZ [35.02 h]; OPERARIO [700.33 h]; OFICIAL [1400.66 h]; PEON [3501.64 h]; VOLQUETES; CISTERNA [175.08 h]; CAMION GRUA BARANDA 3 TN [175.08 h]; CARGADOR FRONTAL; EXCAVADORA SOBRE ORUGAS 180-348 HP; DUMPER DE DESCARGA FRONTA 2 TN; MOTONIVELADORA 145 -150HP [175.08 h]; TRACTOR SOBREORUGAS 300-330HP; TRACTOR SOBREORUGAS 170-220HP; RETROEXCAVADORA; MIXER DE CONCRETO; RODILLO BERMERO; RODILLO LISO VIBR. AUTOPROPULSADO 101-135HP 10-12TN |
